# ГРП путь 417 29.07.2023г.

Schedule from MS Project, 2023-08-03 to 2023-12-27.

## Calendars

- Стандартный: Mon-Sat 09:00-13:00, 14:00-18:00; Sun off.

## Schedule

| ID | WBS | Task | Type | Duration | Start | Finish | Predecessors | Total slack | Free slack | Constraint |
| --- | --- | --- | --- | --- | --- | --- | --- | --- | --- | --- |
| 1 | 1 | **Ж/Д пути от ИЦ до обкаточной линии с удлинением трансбордера** |  | 126d | 2023-08-03 | 2023-12-27 |  | 0d |  |  |
| 2 | 1.1 | Аванс | milestone, manual | 0d | 2023-08-08 | 2023-08-08 |  |  |  |  |
| 3 | 1.2 | Поставка материалов на захватку №1 | milestone | 0d | 2023-08-08 | 2023-08-08 | 2 | 42d | 17d |  |
| 4 | 1.3 | Поставка материалов на захватку №4 | milestone | 0d | 2023-08-10 | 2023-08-10 | 2 | 100d | 3d | start no earlier than 2023-08-10 |
| 5 | 1.4 | Поставка материалов на захватку №5 | milestone | 0d | 2023-08-10 | 2023-08-10 | 2 | 78d | 0d | start no earlier than 2023-08-10 |
| 6 | 1.5 | Поставка материалов на захватку №6 | milestone | 0d | 2023-08-10 | 2023-08-10 | 2 | 49d | 0d | start no earlier than 2023-08-10 |
| 7 | 1.6 | Поставка материалов на захватку №7 | milestone | 0d | 2023-08-08 | 2023-08-08 | 2 | 120d | 0d | start no earlier than 2023-07-31 |
| 8 | 1.7 | Поставка материалов на захватку №8 | milestone | 0d | 2023-08-21 | 2023-08-21 | 2 | 50d | 18d | start no earlier than 2023-08-21 |
| 9 | 1.8 | Поставка материалов на захватку №9 | milestone | 0d | 2023-09-11 | 2023-09-11 | 2 | 17d | 0d | start no earlier than 2023-09-11 |
| 10 | 1.9 | Поставка сэндвич-панелей на 121 цех | manual | 60d | 2023-08-07 | 2023-10-14 | 2 |  |  |  |
| 11 | 1.10 | Перенос бытовки и шлагбаума | milestone, manual | 0d | 2023-09-01 | 2023-09-01 |  |  |  |  |
| 12 | 1.11 | Поставка стрелок и рельс | milestone, manual | 0d | 2023-09-11 | 2023-09-11 |  |  |  |  |
| 13 | 1.12 | Передача очистных сооружений | milestone | 0d | 2023-08-03 | 2023-08-03 |  | 30d | 9d | start no earlier than 2023-08-03 |
| 14 | 1.13 | Срезка труб с этакады вдоль пути №75 и старой котельной | milestone | 0d | 2023-08-14 | 2023-08-14 |  | 21d | 0d | start no earlier than 2023-08-14 |
| 15 | 1.14 | **Демонтаж цеха №75** |  | 18d | 2023-08-07 | 2023-08-26 |  | 11d |  |  |
| 16 | 1.14.1 | Демонтаж цеха №75 |  | 15d | 2023-08-07 | 2023-08-23 |  | 11d | 0d |  |
| 17 | 1.14.2 | Устройство временного ограждения (выход на обкаточный путь) |  | 3d | 2023-08-24 | 2023-08-26 | 16 | 105d |  |  |
| 18 | 1.15 | **Демонтаж эстакады вдоль пути №17** |  | 5d | 2023-08-14 | 2023-08-18 |  | 29d |  |  |
| 19 | 1.15.1 | Демонтаж опор и фундаментов |  | 5d | 2023-08-14 | 2023-08-18 | 14 | 29d | 4d |  |
| 20 | 1.16 | **Захватка №1** |  | 53d | 2023-08-24 | 2023-10-24 |  | 25d |  |  |
| 21 | 1.16.1 | **Переустройство газа** |  | 53d | 2023-08-24 | 2023-10-24 |  | 25d |  |  |
| 22 | 1.16.1.1 | Удаление поросли |  | 3d | 2023-08-24 | 2023-08-26 | 16, 19 | 25d | 0d |  |
| 23 | 1.16.1.2 | Переустройство газа в районе 75 склада |  | 10d | 2023-08-28 | 2023-09-07 | 22, 3 | 25d | 0d |  |
| 24 | 1.16.1.3 | Переустройство оставшегося участка |  | 40d | 2023-09-08 | 2023-10-24 | 23 | 55d |  |  |

| ID | WBS | Task | Duration | Start | Finish | Predecessors | Total slack | Free slack | Constraint |
| --- | --- | --- | --- | --- | --- | --- | --- | --- | --- |
| 25 | 1.17 | **Захватка №3** | 10d | 2023-08-14 | 2023-08-24 |  | 107d |  |  |
| 26 | 1.17.1 | Демонтаж склада ГСМ | 10d | 2023-08-14 | 2023-08-24 | 14 | 107d |  |  |
| 27 | 1.18 | **Захватка №4** | 20d | 2023-08-14 | 2023-09-05 |  | 97d |  |  |
| 28 | 1.18.1 | 131-23-НВК3. Переустройство хозпитьевого водопровода (В1) на участке В1-30 – В1-31 | 20d | 2023-08-14 | 2023-09-05 | 4 | 97d |  | start no earlier than 2023-08-14 |
| 29 | 1.19 | **Захватка №5** | 35d | 2023-08-10 | 2023-09-19 |  | 78d |  |  |
| 30 | 1.19.1 | 131-23-НВК3. Переустройство хозпитьевого водопровода (В1) на участке В1-1 – В1-1А | 35d | 2023-08-10 | 2023-09-19 | 5 | 78d | 0d |  |
| 31 | 1.19.2 | Переустройство трубопровода теплоснабжения. Точка 1 - 9 | 35d | 2023-08-10 | 2023-09-19 | 5 | 78d | 0d |  |
| 32 | 1.19.3 | Хозбытовая канализация (К1) на участке К9-К9б | 35d | 2023-08-10 | 2023-09-19 | 5 | 78d | 0d |  |
| 33 | 1.20 | **Захватка №6** | 47d | 2023-08-10 | 2023-10-03 |  | 32d |  |  |
| 34 | 1.20.1 | 131-23-НВК4. Хозбытовая канализация (К1) на участке К10-К10А | 30d | 2023-08-10 | 2023-09-13 | 6 | 49d | 40d |  |
| 35 | 1.20.2 | 131-23-ЭС2. Электроснабжение. Переустройство кабельных линий. Точки 9-12 | 20d | 2023-09-11 | 2023-10-03 | 6, 8, 9 | 32d | 23d |  |
| 36 | 1.21 | **Захватка №7** | 80d | 2023-08-07 | 2023-11-07 |  | 9d |  |  |
| 37 | 1.21.1 | Переустройство внутрицехового водопровода цеха 121 | 1d | 2023-08-07 | 2023-08-07 |  | 122d |  |  |
| 38 | 1.21.2 | 131-23-ЭС1. Электроснабжение. Переустройство сетей электроснабжения цеха 121 | 2d | 2023-08-08 | 2023-08-09 | 7 | 120d |  |  |
| 39 | 1.21.3 | Демонтаж цеха 121/18 | 38d | 2023-08-07 | 2023-09-19 |  | 9d | 0d |  |
| 40 | 1.21.4 | АС-3 Отделочные работы с монтажом стеновых сэндвич-панелей | 20d | 2023-10-16 | 2023-11-07 | 39, 10 | 43d |  |  |
| 41 | 1.22 | **Захватка №8** | 20d | 2023-09-11 | 2023-10-03 |  | 73d |  |  |
| 42 | 1.22.1 | 131-23-АС-4 переустройство эстакады | 20d | 2023-09-11 | 2023-10-03 | 8, 9 | 73d |  | start no earlier than 2023-08-22 |
| 43 | 1.23 | **Захватка №9** | 45d | 2023-09-20 | 2023-11-10 |  | 9d |  |  |
| 44 | 1.23.1 | 131-23-НВК2. Переустройство хозпитьевого водопровода (В1) к цеху 121/18 | 45d | 2023-09-20 | 2023-11-10 | 39, 9 | 9d | 0d |  |
| 45 | 1.23.2 | 131-23-ЭС2. Электроснабжение. Переустройство кабельных линий. Точки 1-2 | 45d | 2023-09-20 | 2023-11-10 | 44SS | 40d |  |  |
| 46 | 1.23.3 | 131-23-ЭС2. Электроснабжение. Переустройство кабельных линий. Точки 6-7-8 | 45d | 2023-09-20 | 2023-11-10 | 44SS | 40d |  |  |
| 47 | 1.23.4 | 131-23-ЭС2. Электроснабжение. Переустройство кабельных линий. Точки 28-28А-28Б-28В | 45d | 2023-09-20 | 2023-11-10 | 44SS | 40d |  |  |
| 48 | 1.23.5 | 131-23-НВК5. Ливневая канализация (перенос колодца14) | 45d | 2023-09-20 | 2023-11-10 | 44SS | 40d |  |  |
| 49 | 1.23.6 | 131-23-НВК5. Ливневая канализация уч.15-15А-15Б-15В-15Г-15Д-16-16А-17-17А-18-19-20-22 | 45d | 2023-09-20 | 2023-11-10 | 44SS | 40d |  |  |
| 50 | 1.23.7 | 131-23-НВК5.Подключение дождеприемников Д-1 -22 и Д-2-12А нов. | 45d | 2023-09-20 | 2023-11-10 | 44SS | 40d |  |  |
| 51 | 1.23.8 | 131-23-НВК3. Переустройство хозпитьевого водопровода (В1) на участке В1-3А - В1-8 | 45d | 2023-09-20 | 2023-11-10 | 44SS | 40d |  |  |
| 52 | 1.23.9 | 131-23-НВК4. Хозбытовая канализация (К1) на участке К11-К13 | 45d | 2023-09-20 | 2023-11-10 | 44SS | 9d | 0d |  |

| ID | WBS | Task | Duration | Start | Finish | Predecessors | Total slack | Free slack | Constraint |
| --- | --- | --- | --- | --- | --- | --- | --- | --- | --- |
| 53 | 1.24 | **Захватка №10** | 20d | 2023-09-20 | 2023-10-12 |  | 65d |  |  |
| 54 | 1.24.1 | 131-23-ТС2. Переустройство трубопровода теплоснабжения по эстакаде | 20d | 2023-09-20 | 2023-10-12 | 11, 39 | 65d |  |  |
| 55 | 1.25 | **Захватка №11** | 55d | 2023-08-14 | 2023-10-16 |  | 21d |  |  |
| 56 | 1.25.1 | Демонтаж здания очистных | 25d | 2023-08-14 | 2023-09-11 | 13, 14 | 21d | 0d |  |
| 57 | 1.25.2 | Переустройство хозпитьевого водопровода (В1) на участке В1-2 – В1-2А | 30d | 2023-09-12 | 2023-10-16 | 56 | 62d |  |  |
| 58 | 1.25.3 | 131-23-НВК5. Ливневая канализация (кол.26-27) | 30d | 2023-09-12 | 2023-10-16 | 56 | 21d | 12d |  |
| 59 | 1.26 | **Захватка №12 (Трансбордер)** | 69d | 2023-08-08 | 2023-10-26 |  | 53d |  |  |
| 60 | 1.26.1 | 131-23-АС2. Перенос забора | 25d | 2023-08-08 | 2023-09-05 |  | 53d | 0d | start no earlier than 2023-08-08 |
| 61 | 1.26.2 | 131-23-НВК1. Наружные сети водопровода и канализации | 25d | 2023-08-12 | 2023-09-09 | 60SS+4d | 93d |  |  |
| 62 | 1.26.3 | 131-23-ТС1. Переустройство трассы теплоснабжения | 32d | 2023-08-12 | 2023-09-18 | 60SS+4d | 53d | 0d |  |
| 63 | 1.26.4 | 131-23-АС1. Переустройство Трансбордера | 45d | 2023-08-18 | 2023-10-09 | 62SS+5d | 53d | 0d |  |
| 64 | 1.26.5 | 131-23-ГП1. Генеральный план | 15d | 2023-10-10 | 2023-10-26 | 63 | 53d |  |  |
| 65 | 1.27 | **Ж/д пути** | 108d | 2023-08-24 | 2023-12-27 |  | 0d |  |  |
| 66 | 1.27.1 | **Работы в районе обкаточного пути** | 46d | 2023-08-24 | 2023-10-16 |  | 11d |  |  |
| 67 | 1.27.1.1 | Переустройство контактной сети | 20d | 2023-08-24 | 2023-09-15 | 16 | 88d |  |  |
| 68 | 1.27.1.2 | Демонтаж старогодней стрелки №8 (переносится на стрелочный перевода №40) | 4d | 2023-08-24 | 2023-08-28 | 16 | 11d | 0d |  |
| 69 | 1.27.1.3 | Демонтаж пути сп.№8-сп.№42 (110п.м.) | 4d | 2023-08-24 | 2023-08-28 | 68SS | 11d | 0d |  |
| 70 | 1.27.1.4 | Устройство пути вместо стрелочного перевода №8 (80 п.м.) | 7d | 2023-08-29 | 2023-09-05 | 69 | 90d | 20d |  |
| 71 | 1.27.1.5 | Устройство стрелочного перевода №40 | 8d | 2023-09-11 | 2023-09-19 | 69, 12 | 0d |  |  |
| 72 | 1.27.1.6 | Устройство стрелочного перевода №41 | 8d | 2023-09-11 | 2023-09-19 | 68SS, 12 | 8d |  |  |
| 73 | 1.27.1.7 | Устройство стрелочного перевода №42 | 8d | 2023-09-20 | 2023-09-28 | 71, 12 | 0d |  |  |
| 74 | 1.27.1.8 | Устройство ж/д пути от сп.№40 до сп.№42 (50 п.м) | 7d | 2023-09-29 | 2023-10-06 | 70, 73 | 70d |  |  |
| 75 | 1.27.1.9 | Устройство ж/д путей до ГП№44 | 7d | 2023-09-29 | 2023-10-06 | 73, 72 | 0d |  |  |
| 76 | 1.27.1.10 | Устройство ГП№44 | 8d | 2023-10-07 | 2023-10-16 | 75, 23 | 0d |  |  |
| 77 | 1.27.2 | Устройство ж/д путей до стрелочного перевода №46 (путь №30) | 20d | 2023-10-17 | 2023-11-08 | 76 | 0d |  |  |

| ID | WBS | Task | Duration | Start | Finish | Predecessors | Total slack | Free slack |
| --- | --- | --- | --- | --- | --- | --- | --- | --- |
| 78 | 1.27.3 | **Переустройство пути №17** | 42d | 2023-11-09 | 2023-12-27 |  | 0d |  |
| 79 | 1.27.3.1 | Устройство стрелочного перевода №46 | 7d | 2023-11-09 | 2023-11-16 | 77 | 0d |  |
| 80 | 1.27.3.2 | Устройство стрелочного перевода №48 | 7d | 2023-11-17 | 2023-11-24 | 79 | 0d |  |
| 81 | 1.27.3.3 | Устройство стрелочного перевода № 50 | 7d | 2023-11-25 | 2023-12-02 | 80 | 0d |  |
| 82 | 1.27.3.4 | Устройство ж/д путей №32,34,36 | 17d | 2023-12-04 | 2023-12-22 | 81 | 0d |  |
| 83 | 1.27.3.5 | Установка тупиков №1,2,3 | 4d | 2023-12-23 | 2023-12-27 | 82 | 0d |  |
| 84 | 1.27.4 | Устройство ж/д пути до стрелочного перевода №43 (путь №31) | 25d | 2023-10-31 | 2023-11-28 | 76, 58, 52FS-10d, 34, 35 | 9d | 0d |
| 85 | 1.27.5 | Устройство стрелочного перевода №43 | 8d | 2023-11-29 | 2023-12-07 | 84 | 9d | 0d |
| 86 | 1.27.6 | Устройство стрелочного перевода №45 | 8d | 2023-12-08 | 2023-12-16 | 85 | 9d |  |
| 87 | 1.27.7 | Устройство стрелочного перевода №47 | 8d | 2023-12-08 | 2023-12-16 | 85 | 9d |  |
| 88 | 1.27.8 | **Переустройство СП №22 (путь 23)** | 7d | 2023-09-20 | 2023-09-27 |  | 78d |  |
| 89 | 1.27.8.1 | Демонтаж стрелочного перевода №22 | 3d | 2023-09-20 | 2023-09-22 | 30, 31, 32 | 78d | 0d |
| 90 | 1.27.8.2 | Устройсто ж/д пути вместо сп.№22 | 4d | 2023-09-23 | 2023-09-27 | 89 | 78d |  |
| 91 | 1.27.9 | **Переустройство СП №14 (путь 18)** | 9d | 2023-11-09 | 2023-11-18 |  | 33d |  |
| 92 | 1.27.9.1 | Демонтаж стрелочного перевода №16 | 4d | 2023-11-09 | 2023-11-13 | 77 | 33d | 0d |
| 93 | 1.27.9.2 | Демонтаж стрелочного перевода №14 | 4d | 2023-11-09 | 2023-11-13 | 77 | 33d | 0d |
| 94 | 1.27.9.3 | Устройсто ж/д пути вместо сп.№14 | 4d | 2023-11-14 | 2023-11-17 | 92, 93 | 33d | 0d |
| 95 | 1.27.9.4 | Установка тупика №4 | 1d | 2023-11-18 | 2023-11-18 | 94 | 33d |  |
